# 2-2

Schedule from MS Project, 2023-09-15 to 2024-04-02, 2 hours a day, costs in €, A marks actual dates.
Universite Clermont Auvergne

## Calendars

- SAE: Mon 08:00-10:00, 13:30-17:30; Tue 08:00-10:00; Wed 08:00-10:00, 13:30-16:30; Thu 08:00-10:00; Fri 08:00-10:00, 13:30-16:30; Sat-Sun off. Exceptions (off unless hours are given): 2023-11-20 to 2023-11-26 08:00-12:00, 13:30-16:30, 2024-01-03 to 2024-01-07 08:00-10:00, 13:30-16:30, 2024-01-08 to 2024-01-13 08:00-10:00, 13:30-17:30, 2024-03-25 to 2024-04-03 08:00-12:00, 13:30-16:30.

## Resources

| Resource | Rate |
| --- | --- |
| A_PE | 20 |
| K_MO | 20 |
| P_LE | 20 |
| D_DA | 20 |
| A_PI | 20 |

## Schedule

| ID | WBS | Task | Duration | Start | Finish | Predecessors | Complete | Remaining | Baseline start | Baseline finish | Baseline duration | Total slack | Free slack | Resources | Work | Actual work | Cost | Baseline cost | Actual cost |
| --- | --- | --- | --- | --- | --- | --- | --- | --- | --- | --- | --- | --- | --- | --- | --- | --- | --- | --- | --- |
| 1 | 1 | **Étude de courbes de fréquence cardiaque** | 334.25d | 2023-09-15 A | 2024-04-02 |  | 52% | 160.29d | 2023-09-15 | 2024-04-04 | 144.83d | 0d |  |  | 491.83h | 262.11h | 9,836.5 | 11,159.78 | 5,242.23 |
| 2 | 1.1 | **1 - Management de projet** | 334.25d | 2023-09-15 A | 2024-04-02 |  | 84% | 53.16d | 2023-09-15 | 2024-04-04 | 144.83d | 0d |  |  | 168.02h | 132.88h | 3,360.37 | 3,320 | 2,657.57 |
| 3 | 1.1.1 | **1.1 - Recueil de besoins** | 43.25d | 2023-09-15 A | 2023-10-16 |  | 84% | 6.79d | 2023-09-15 | 2023-10-16 | 21.75d | 291d |  |  | 75h | 68.38h | 1,500 | 1,500 | 1,367.5 |
| 4 | 1.1.1.1 | 1.1.1 - Présentation general du projet | 2h | 2023-09-20 A | 2023-09-21 A | 11 | 100% |  | 2023-09-20 | 2023-09-21 | 2h |  |  | A_PE | 2h | 2h | 40 | 40 | 40 |
| 5 | 1.1.1.2 | 1.1.2 - Compte rendu 1 | 3h | 2023-09-21 A | 2023-09-25 A | 4, 10 | 100% |  | 2023-09-21 | 2023-09-25 | 3h |  |  | A_PE; A_PI; D_DA; K_MO; P_LE | 7h | 7h | 140 | 140 | 140 |
| 6 | 1.1.1.3 | 1.1.3 - Compte rendu 2 | 14h | 2023-09-28 A | 2023-10-13 A | 7 | 100% |  | 2023-09-28 | 2023-10-13 | 14h |  |  | A_PE; A_PI; D_DA; K_MO; P_LE | 25h | 25h | 500 | 500 | 500 |
| 7 | 1.1.1.4 | 1.1.4 - Backlog (users stories) | 5h | 2023-09-25 A | 2023-09-28 A | 5 | 100% |  | 2023-09-25 | 2023-09-28 | 5h |  |  | D_DA; P_LE | 10h | 10h | 200 | 200 | 200 |
| 8 | 1.1.1.5 | 1.1.7 - Rapport BDD | 6.7h | 2023-10-09 A | 2023-10-16 A | 34 | 100% |  | 2023-10-09 | 2023-10-16 | 6h |  |  | A_PE; P_LE; D_DA; K_MO; A_PI | 10h | 10h | 200 | 200 | 200 |
| 9 | 1.1.1.6 | **1.1.5 - Rendez vous** | 8.25d | 2023-09-15 A | 2023-09-20 |  | 42% | 4.75d | 2023-09-15 | 2023-09-21 | 4.75d | 326d |  |  | 21h | 14.38h | 420 | 420 | 287.5 |
| 10 | 1.1.1.6.1 | 1.1.5.1 - Avec le tuteur | 6.5h | 2023-09-15 A | 2023-09-20 |  | 75% | 1.62h | 2023-09-15 | 2023-09-21 | 6.5h | 326d |  | A_PE; A_PI; D_DA; K_MO; P_LE | 16h | 14.38h | 320 | 320 | 287.5 |
| 11 | 1.1.1.6.2 | 1.1.5.2 - Avec le client | 5h | 2023-09-15 | 2023-09-18 |  |  |  | 2023-09-15 | 2023-09-20 | 4h | 10.45d | 1.75d | A_PE; A_PI; D_DA; K_MO; P_LE | 5h |  | 100 | 100 |  |
| 12 | 1.1.2 | **1.2 - Organisation du travail en équipe** | 20.75d | 2023-09-15 A | 2023-09-29 A |  | 100% |  | 2023-09-15 | 2023-09-29 | 10.75d |  |  |  | 8h | 8h | 160 | 160 | 160 |
| 13 | 1.1.2.1 | 1.2.1 - Mise en place du kanban | 2h | 2023-09-15 A | 2023-09-28 A |  | 100% |  | 2023-09-15 | 2023-09-28 | 2h |  |  | A_PE; D_DA | 2h | 2h | 40 | 40 | 40 |
| 14 | 1.1.2.2 | 1.2.2 - Mise en place du codefirst | 3h | 2023-09-28 A | 2023-09-29 A |  | 100% |  | 2023-09-28 | 2023-09-29 | 3h |  |  | D_DA | 3h | 3h | 60 | 60 | 60 |
| 15 | 1.1.2.3 | 1.2.3 - Mise en place du notion | 2h | 2023-09-15 A | 2023-09-19 A |  | 100% |  | 2023-09-15 | 2023-09-19 | 2h |  |  | D_DA; A_PE | 2h | 2h | 40 | 40 | 40 |
| 16 | 1.1.2.4 | 1.2.4 - Mise en place du discord | 0.5h | 2023-09-15 A | 2023-09-15 A |  | 100% |  | 2023-09-15 | 2023-09-15 | 0.5h |  |  | A_PE; A_PI | 1h | 1h | 20 | 20 | 20 |
| 17 | 1.1.3 | **1.3 - Planification du projet** | 26d | 2023-09-25 A | 2023-10-12 A |  | 100% |  | 2023-09-25 | 2023-10-12 | 12.5d |  |  |  | 24h | 24h | 480 | 480 | 480 |
| 18 | 1.1.3.1 | 1.3.1 - WBS | 6.5h | 2023-09-25 A | 2023-09-29 A | 5 | 100% |  | 2023-09-25 | 2023-09-29 | 6.5h |  |  | A_PE; K_MO | 10h | 10h | 200 | 200 | 200 |
| 19 | 1.1.3.2 | 1.3.2 - GANTT prévisionnel | 10h | 2023-09-29 A | 2023-10-10 A | 18 | 100% |  | 2023-09-29 | 2023-10-10 | 10h |  |  | A_PE; P_LE | 10h | 10h | 200 | 200 | 200 |
| 20 | 1.1.3.3 | 1.3.3 - PERT | 4h | 2023-10-10 A | 2023-10-12 A | 19 | 100% |  | 2023-10-10 | 2023-10-12 | 4h |  |  | A_PE; P_LE | 4h | 4h | 80 | 80 | 80 |
| 21 | 1.1.4 | **1.4 - Suivi de projet** | 295d | 2023-10-12 A | 2024-04-02 |  | 66% | 100.48d | 2023-10-12 | 2024-04-04 | 125.58d | 0d |  |  | 61.02h | 32.5h | 1,220.37 | 1,180 | 650.07 |
| 22 | 1.1.4.1 | 1.4.1 - Indicateurs de suivi de projet | 4h | 2023-10-12 A | 2023-10-16 A | 20 | 100% |  | 2023-10-12 | 2023-10-16 | 4h |  |  | D_DA; A_PE | 4h | 4h | 80 | 80 | 80 |
| 23 | 1.1.4.2 | 1.4.2 - Préparation des vidéos | 3h | 2024-03-28 | 2024-03-28 | 24 |  |  | 2024-02-27 | 2024-02-29 | 3h | 17.48d |  | A_PE; A_PI; D_DA; K_MO; P_LE | 15h |  | 300 | 300 |  |
| 24 | 1.1.4.3 | 1.4.3 - Préparation des rapports globaux | 2h | 2024-03-27 | 2024-03-28 | 63 |  |  | 2024-02-26 | 2024-02-27 | 2h | 17.48d | 0d | A_PE; A_PI; D_DA; K_MO; P_LE | 10h |  | 200 | 200 |  |
| 25 | 1.1.4.4 | 1.4.4 - Préparation oral 1 | 7h | 2023-10-16 A | 2023-10-26 A | 22 | 100% |  | 2023-10-16 | 2023-10-26 | 5h |  |  | A_PE; A_PI; D_DA; K_MO; P_LE | 13h | 13h | 260 | 260 | 260 |
| 26 | 1.1.4.5 | 1.4.5 - Préparation oral 2 | 4h | 2023-10-27 A | 2023-11-26 | 25 | 99% | 0.01h | 2023-10-27 | 2023-12-18 | 4.98h | 217.25d |  | A_PE; A_PI; K_MO; P_LE | 14.02h | 14h | 280.37 | 300 | 280.07 |
| 27 | 1.1.4.6 | 1.4.6 - GANTT réel | 5h | 2024-03-27 A | 2024-04-02 | 63 | 30% | 3.5h | 2024-02-26 | 2024-04-04 | 2h | 0d |  | A_PI; A_PE | 5h | 1.5h | 100 | 40 | 30 |

| ID | WBS | Task | Type | Duration | Start | Finish | Predecessors | Complete | Remaining | Baseline start | Baseline finish | Baseline duration | Total slack | Free slack | Constraint | Resources | Work | Actual work | Cost | Baseline cost | Actual cost |
| --- | --- | --- | --- | --- | --- | --- | --- | --- | --- | --- | --- | --- | --- | --- | --- | --- | --- | --- | --- | --- | --- |
| 28 | 1.2 | **2 - Développement** |  | 307.02d | 2023-09-20 A | 2024-03-27 |  | 40% | 183.38d | 2023-09-20 | 2024-02-26 | 112.75d | 19.98d |  |  |  | 323.81h | 129.23h | 6,476.13 | 7,839.78 | 2,584.67 |
| 29 | 1.2.1 | **2.1 - Conception** |  | 96d | 2023-09-20 A | 2023-11-23 |  | 71% | 28.11d | 2023-09-20 | 2023-12-15 | 62.1d | 231d |  |  |  | 68.41h | 52.01h | 1,368.17 | 1,544.62 | 1,040.17 |
| 30 | 1.2.1.1 | 2.1.1 - Communication (reseaux) |  | 7h | 2023-11-15 A | 2023-11-23 | 31 | 10% | 6.3h | 2023-11-15 | 2023-12-15 | 7h | 181.77d | 0d |  | A_PE; P_LE | 7h | 0.7h | 140 | 140 | 14 |
| 31 | 1.2.1.2 | 2.1.2 - Architecture |  | 10h | 2023-11-08 A | 2023-11-13 | 32 | 15% | 8.5h | 2023-11-08 | 2023-11-15 | 10h | 5.35d | 0d |  | A_PE; D_DA | 10h | 1.5h | 200 | 200 | 30 |
| 32 | 1.2.1.3 | 2.1.3 - Diagramme de classes |  | 10h | 2023-10-09 A | 2023-11-03 A | 34 | 100% |  | 2023-10-09 | 2023-11-08 | 10h |  |  |  | A_PE; A_PI; D_DA | 11.41h | 11.41h | 228.17 | 404.62 | 228.17 |
| 33 | 1.2.1.4 | 2.1.4 - Maquettes |  | 8h | 2023-09-25 A | 2023-09-29 A | 5 | 100% |  | 2023-09-25 | 2023-09-29 | 8h |  |  |  | A_PI | 8h | 8h | 160 | 160 | 160 |
| 34 | 1.2.1.5 | 2.1.5 - MCD & MLD |  | 12h | 2023-09-29 A | 2023-10-09 A | 33 | 100% |  | 2023-09-29 | 2023-10-09 | 12h |  |  |  | D_DA; P_LE; K_MO; A_PI; A_PE | 23h | 23h | 460 | 460 | 460 |
| 35 | 1.2.1.6 | 2.1.6 - Diagramme de cas d'utilisation |  | 8h | 2023-09-20 A | 2023-09-27 | 11 | 80% | 1.6h | 2023-09-20 | 2023-09-29 | 8h | 317.5d |  |  | K_MO; A_PE | 8h | 6.4h | 160 | 160 | 128 |
| 36 | 1.2.1.7 | 2.1.8 - Logo |  | 1h | 2023-10-05 A | 2023-10-05 A |  | 100% |  | 2023-10-05 | 2023-10-05 | 1h |  |  |  | D_DA | 1h | 1h | 20 | 20 | 20 |
| 37 | 1.2.2 | **2.2 - Client Web et Mobile** |  | 198.04d | 2023-11-15 A | 2024-03-11 |  | 72% | 55.83d | 2023-11-15 | 2024-02-05 | 58.14d | 48.86d |  |  |  | 88.66h | 58.79h | 1,773.27 | 2,937.27 | 1,175.87 |
| 38 | 1.2.2.1 | 2.2.1 - Interface utilisateur client (Vues) |  | 15h | 2023-11-20 A | 2023-12-22 | 31 | 90% | 1.5h | 2023-11-20 | 2024-01-09 | 15h | 179.45d |  |  | A_PI | 15h | 13.5h | 300 | 300 | 270 |
| 39 | 1.2.2.2 | 2.2.2 - Gestion des données client |  | 30h | 2023-11-15 A | 2023-11-23 | 31 | 53% | 14.06h | 2023-11-15 | 2023-12-13 | 40h | 37.8d | 35.35d |  | A_PE; D_DA; P_LE | 50.16h | 25.54h | 1,003.27 | 2,167.27 | 510.87 |
| 40 | 1.2.2.3 | 2.2.3 - Authentification Web et Mobile client |  | 3h | 2024-01-29 A | 2024-03-11 | 30, 39, 43, 44, 45 | 75% | 0.75h | 2023-12-25 | 2024-02-05 | 3h | 48.86d |  |  | A_PI; K_MO; D_DA | 3h | 2.25h | 60 | 60 | 45 |
| 41 | 1.2.2.4 | 2.2.4 - Récupération des données de fréquence cardiaque |  | 15h | 2023-11-15 A | 2023-11-29 | 31 | 80% | 3h | 2023-11-15 | 2023-12-28 | 15h | 211.14d |  |  | A_PE | 15h | 12h | 300 | 300 | 240 |
| 42 | 1.2.2.5 | 2.2.5 - Définitions des algoritmes d'analyse de la fréquence cardiaque | milestone | 0h | 2023-11-23 | 2023-11-24 | 30 |  |  | 2023-12-15 | 2023-12-22 | 0h | 224.25d |  |  | D_DA |  |  |  |  |  |
| 43 | 1.2.2.6 | 2.2.6 - Mise en place Bootstrap |  | 3h | 2023-11-15 A | 2023-11-17 A | 31, 35 | 100% |  | 2023-11-15 | 2023-11-17 | 3h |  |  |  | A_PI | 3h | 3h | 60 | 60 | 60 |
| 44 | 1.2.2.7 | 2.2.7 - Mise en place talwind |  | 1.5h | 2023-11-17 A | 2023-11-20 A | 31, 35 | 100% |  | 2023-11-17 | 2023-11-20 | 1.5h |  |  |  | A_PI | 1.5h | 1.5h | 30 | 30 | 30 |
| 45 | 1.2.2.8 | 2.2.8 - Mise en place lead PHPStorm |  | 1h | 2024-01-29 A | 2024-01-29 A | 31, 35 | 100% |  | 2023-12-22 | 2023-12-25 | 1h |  |  |  | D_DA | 1h | 1h | 20 | 20 | 20 |
| 46 | 1.2.3 | **2.3 - Web admin et monitorin** |  | 26.15d | 2023-11-13 | 2023-11-24 |  |  |  | 2023-11-22 | 2024-01-01 | 27.38d | 224.25d |  |  |  | 23.28h |  | 465.57 | 465.57 |  |
| 47 | 1.2.3.1 | 2.3.1 - Authentification admin et monitoring |  | 9.51h | 2023-11-23 | 2023-11-24 | 30 |  |  | 2023-12-25 | 2024-01-01 | 9.51h | 224.25d |  |  | A_PE; D_DA | 13.28h |  | 265.57 | 265.57 |  |
| 48 | 1.2.3.2 | 2.3.2 - Interface utilisateur admin (Vues) |  | 10h | 2023-11-13 | 2023-11-17 | 31 |  |  | 2023-11-22 | 2023-12-01 | 10h | 243.15d |  |  | A_PI | 10h |  | 200 | 200 |  |
| 49 | 1.2.4 | **2.4 - Base de données** |  | 131.15d | 2023-12-13 A | 2024-03-01 |  | 14% | 112.6d | 2023-12-13 | 2024-02-13 | 43.35d | 61.25d |  |  |  | 23.55h | 3.33h | 471 | 471 | 66.63 |
| 50 | 1.2.4.1 | 2.4.1 - Création des tables |  | 2h | 2023-12-13 A | 2023-12-14 | 39 | 95% | 0.1h | 2023-12-13 | 2023-12-14 | 2h | 1.12d | 0d |  | P_LE | 2h | 1.9h | 40 | 40 | 38 |
| 51 | 1.2.4.2 | 2.4.2 - Ajout des données |  | 1.55h | 2023-12-15 A | 2023-12-23 | 50 | 15% | 1.32h | 2023-12-15 | 2023-12-22 | 1.55h | 172.25d | 111d |  | A_PE; D_DA | 1.55h | 0.23h | 31 | 31 | 4.63 |
| 52 | 1.2.4.3 | 2.4.3 - Mise en place d'un système de backup |  | 12h | 2023-12-14 A | 2024-01-19 | 50 | 10% | 10.8h | 2023-12-14 | 2024-02-12 | 7.67h | 116.88d | 55.63d |  | A_PE; D_DA | 12h | 1.2h | 240 | 240 | 24 |
| 53 | 1.2.4.4 | 2.4.4 - Création des fonctions |  | 4h | 2023-12-14 | 2023-12-15 | 50 |  |  | 2023-12-15 | 2023-12-19 | 4h | 187.9d |  |  | A_PI | 4h |  | 80 | 80 |  |
| 54 | 1.2.4.5 | 2.4.5 - Création des index |  | 4h | 2024-02-27 | 2024-03-01 | 51, 52 |  |  | 2024-02-12 | 2024-02-13 | 2h | 61.25d |  | start no earlier than 2024-02-27 | A_PE; D_DA | 4h |  | 80 | 80 |  |

| ID | WBS | Task | Duration | Start | Finish | Predecessors | Complete | Remaining | Baseline start | Baseline finish | Baseline duration | Total slack | Free slack | Constraint | Resources | Work | Actual work | Cost | Baseline cost | Actual cost |
| --- | --- | --- | --- | --- | --- | --- | --- | --- | --- | --- | --- | --- | --- | --- | --- | --- | --- | --- | --- | --- |
| 55 | 1.2.5 | **2.5 - Serveur et communication de services** | 75.4d | 2023-11-13 | 2023-12-25 |  |  |  | 2023-11-15 | 2024-02-09 | 61.6d | 175d |  |  |  | 47.07h |  | 941.33 | 941.33 |  |
| 56 | 1.2.5.1 | 2.5.1 - Authentification serveur | 4h | 2023-11-23 | 2023-12-08 | 30 |  |  | 2023-12-15 | 2024-01-31 | 4h | 184.04d | 6.75d |  | A_PI; K_MO | 4h |  | 80 | 80 |  |
| 57 | 1.2.5.2 | 2.5.2 - Stockage cloud | 10.17h | 2023-12-13 | 2023-12-24 | 56, 58 |  |  | 2024-01-31 | 2024-02-02 | 3.5h | 174.75d | 0d | start no earlier than 2023-12-13 | D_DA; A_PE; A_PI | 10.17h |  | 203.33 | 203.33 |  |
| 58 | 1.2.5.3 | 2.5.3 - Routage | 17.9h | 2023-11-13 | 2023-11-28 | 31 |  |  | 2023-11-15 | 2024-01-12 | 14.4h | 195.74d | 22.93d |  | A_PE; A_PI; D_DA | 17.9h |  | 358 | 358 |  |
| 59 | 1.2.5.4 | 2.5.4 - Gestion des données serveur | 5.5h | 2023-12-24 | 2023-12-25 | 57 |  |  | 2024-02-02 | 2024-02-09 | 10.17h | 174.75d |  |  | A_PI; A_PE; D_DA | 15h |  | 300 | 300 |  |
| 60 | 1.2.6 | **2.6 - Integration continue et livraison continue (CI/ CD)** | 226.92d | 2023-11-15 A | 2024-03-27 |  | 23% | 175.52d | 2023-11-15 | 2024-02-26 | 72.66d | 19.98d |  |  |  | 72.84h | 15.1h | 1,456.8 | 1,480 | 302 |
| 61 | 1.2.6.1 | 2.6.1 - Tests | 40h | 2023-11-15 A | 2023-12-23 | 31 | 21% | 31.47h | 2023-11-15 | 2024-01-23 | 40h | 154.72d | 110.51d |  | A_PE; A_PI; D_DA; K_MO; P_LE | 46.84h | 9.6h | 936.8 | 960 | 192 |
| 62 | 1.2.6.2 | 2.6.2 - Conteneurisation et déploiement | 8h | 2023-11-15 A | 2023-12-06 | 31 | 35% | 5.2h | 2023-11-15 | 2024-01-23 | 8h | 202.99d |  |  | A_PE; D_DA | 8h | 2.8h | 160 | 160 | 56 |
| 63 | 1.2.6.3 | 2.6.3 - Documentations (swagger, schéma, …) | 6h | 2024-02-27 A | 2024-03-27 | 61 | 15% | 5.1h | 2024-01-23 | 2024-02-26 | 6h | 17.48d | 0d |  | A_PE; A_PI; D_DA | 18h | 2.7h | 360 | 360 | 54 |
